Schedule from MS Project, 2005-11-08 to 2005-12-10.
_

## Calendars

- Estándar: Mon 12:00-14:00; Tue 12:00-14:00, 16:30-19:10; Wed 12:00-14:00; Thu 12:00-14:00, 17:25-20:20; Fri 12:00-14:00, 18:20-20:20; Sat-Sun off.
- Calendario de trabajo: Mon 10:00-14:00; Tue 10:00-14:00, 16:30-19:10; Wed 10:00-14:00; Thu 10:00-14:00, 17:25-20:20; Fri 10:00-14:00, 18:20-20:20; Sat 10:00-14:00; Sun off. Exceptions (off unless hours are given): 2005-11-08 10:00-14:00, 16:30-19:10.
- Calendario de clase: Mon off; Tue 16:30-19:10; Wed off; Thu 17:25-20:20; Fri 18:20-20:20; Sat-Sun off.

## Resources

| Resource |
| --- |
| ordenador |
| Laboratorio B16 |
| Laboratorio prototipos |
| técnico DPE |
| profesor |

## Schedule

| ID | WBS | Task | Type | Duration | Start | Finish | Predecessors | Baseline start | Baseline finish | Baseline duration | Total slack | Free slack | Calendar | Resources | Work |
| --- | --- | --- | --- | --- | --- | --- | --- | --- | --- | --- | --- | --- | --- | --- | --- |
| 1 | 1 | inicio del proyecto | milestone | 0d | 2005-11-08 | 2005-11-08 |  | 2005-11-08 | 2005-11-08 | 0d | 0.27d | 0.25d |  |  |  |
| 2 | 2 | **estudios previos** |  | 3.38d | 2005-11-08 | 2005-11-17 |  | 2005-11-08 | 2005-11-17 | 3.38d | 0.02d |  |  |  | 15h |
| 3 | 2.1 | estudio del LM35 |  | 3h | 2005-11-15 | 2005-11-17 | 1 | 2005-11-15 | 2005-11-17 | 3h | 0.02d | 0d | Calendario de clase | profesor | 3h |
| 4 | 2.2 | estudio de la conversión A/D |  | 2h | 2005-11-08 | 2005-11-08 | 1 | 2005-11-08 | 2005-11-08 | 2h | 0.9d | 0d | Calendario de clase | profesor; técnico DPE | 4h |
| 5 | 2.3 | estudio del PIC16F88 |  | 4h | 2005-11-08 | 2005-11-11 | 4 | 2005-11-08 | 2005-11-11 | 4h | 0.9d |  | Calendario de clase | profesor | 4h |
| 6 | 2.4 | estudio de MS-Project |  | 4h | 2005-11-11 | 2005-11-15 | 1 | 2005-11-11 | 2005-11-15 | 4h | 0.4d |  | Calendario de clase | profesor | 4h |
| 7 | 3 | **realización del hardware** |  | 7.09d | 2005-11-17 | 2005-12-09 |  | 2005-11-17 | 2005-12-09 | 7.09d | 0d |  |  |  | 27h |
| 8 | 3.1 | **realización del prototipo en wrapping** |  | 4.84d | 2005-11-17 | 2005-12-02 |  | 2005-11-17 | 2005-12-02 | 4.84d | 0d |  |  |  | 19h |
| 9 | 3.1.1 | diseño del sistema |  | 3h | 2005-11-17 | 2005-11-18 | 3, 5, 6 | 2005-11-17 | 2005-11-18 | 3h | 0.22d | 0d | Calendario de trabajo | ordenador; técnico DPE | 3h |
| 10 | 3.1.2 | montaje |  | 2h | 2005-11-18 | 2005-11-18 | 9 | 2005-11-18 | 2005-11-18 | 2h | 0.07d |  | Calendario de clase | técnico DPE; Laboratorio B16 | 2h |
| 11 | 3.1.3 | puebas del sistema de visualización |  | 7h | 2005-11-22 | 2005-11-25 | 10, 21 | 2005-11-22 | 2005-11-25 | 7h | 0.07d |  | Calendario de clase | técnico DPE; Laboratorio B16 | 7h |
| 12 | 3.1.4 | pruebas del prototipo |  | 7h | 2005-11-29 | 2005-12-02 | 11, 23 | 2005-11-29 | 2005-12-02 | 7h | 0d |  | Calendario de clase | técnico DPE; Laboratorio B16 | 7h |
| 13 | 3.2 | **realización del circuito impreso** |  | 2.25d | 2005-12-02 | 2005-12-09 |  | 2005-12-02 | 2005-12-09 | 2.25d | 0d |  |  |  | 8h |
| 14 | 3.2.1 | realización de la placa |  | 2h | 2005-12-02 | 2005-12-06 | 12, 23 | 2005-12-02 | 2005-12-06 | 2h | 0d |  | Calendario de clase | técnico DPE; Laboratorio prototipos | 2h |
| 15 | 3.2.2 | comprobación de la placa |  | 1h | 2005-12-06 | 2005-12-06 | 14 | 2005-12-06 | 2005-12-06 | 1h | 0d |  | Calendario de clase | técnico DPE; Laboratorio B16 | 1h |
| 16 | 3.2.3 | montaje de componentes |  | 1h | 2005-12-06 | 2005-12-08 | 15 | 2005-12-06 | 2005-12-08 | 1h | 0d |  | Calendario de clase | técnico DPE; Laboratorio B16 | 1h |
| 17 | 3.2.4 | pruebas de la placa |  | 4h | 2005-12-08 | 2005-12-09 | 16 | 2005-12-08 | 2005-12-09 | 4h | 0d |  | Calendario de clase | técnico DPE; Laboratorio B16 | 4h |
| 18 | 4 | **realización del software** |  | 2.59d | 2005-11-18 | 2005-11-26 |  | 2005-11-18 | 2005-11-26 | 2.59d | 0.4d |  |  |  | 28h |
| 19 | 4.1 | diseño de alto nivel |  | 2h | 2005-11-18 | 2005-11-19 | 9 | 2005-11-18 | 2005-11-19 | 2h | 0.4d | 0d | Calendario de trabajo | técnico DPE | 2h |
| 20 | 4.2 | rutinas de adquisición de temperatura |  | 6h | 2005-11-22 | 2005-11-23 | 19 | 2005-11-22 | 2005-11-23 | 6h | 1.72d | 0.25d | Calendario de trabajo | ordenador; técnico DPE | 6h |
| 21 | 4.3 | rutinas de visualización de datos |  | 8h | 2005-11-19 | 2005-11-22 | 19 | 2005-11-19 | 2005-11-22 | 8h | 0.47d | 0.25d | Calendario de trabajo | ordenador; técnico DPE | 8h |
| 22 | 4.4 | rutinas de temporización |  | 4h | 2005-11-23 | 2005-11-24 | 19 | 2005-11-23 | 2005-11-24 | 4h | 1.22d | 0d | Calendario de trabajo | ordenador; técnico DPE | 4h |
| 23 | 4.5 | ensamblaje y simulación |  | 8h | 2005-11-24 | 2005-11-26 | 20, 21, 22 | 2005-11-24 | 2005-11-26 | 8h | 1.22d | 0d | Calendario de trabajo | ordenador; técnico DPE | 8h |
| 24 | 5 | **realización de la documentación** |  | 4.4d | 2005-11-26 | 2005-12-10 |  | 2005-11-26 | 2005-12-10 | 4.4d | 0d |  |  |  | 20h |
| 25 | 5.1 | memoria descriptiva |  | 6h | 2005-12-02 | 2005-12-06 | 12, 23 | 2005-12-05 | 2005-12-06 | 6h | 2.95d | 1.95d | Calendario de trabajo | técnico DPE; ordenador | 6h |
| 26 | 5.2 | diseño de hardware |  | 4h | 2005-12-02 | 2005-12-03 | 12 | 2005-12-03 | 2005-12-03 | 4h | 0.92d | 0d | Calendario de trabajo | técnico DPE; ordenador | 4h |
| 27 | 5.3 | diseño de software |  | 4h | 2005-11-26 | 2005-11-28 | 23 | 2005-11-26 | 2005-11-28 | 4h | 4.51d | 2.17d | Calendario de trabajo | técnico DPE; ordenador | 4h |
| 28 | 5.4 | planos |  | 1h | 2005-12-09 | 2005-12-10 | 12, 17 | 2005-12-09 | 2005-12-10 | 1h | 0d |  | Calendario de trabajo | técnico DPE; ordenador | 1h |
| 29 | 5.5 | presupesto |  | 1h | 2005-12-09 | 2005-12-10 | 23, 17 | 2005-12-10 | 2005-12-10 | 1h | 0d |  | Calendario de trabajo | técnico DPE; ordenador | 1h |
| 30 | 5.6 | manual del usuario |  | 2h | 2005-12-06 | 2005-12-06 | 26, 27 | 2005-12-06 | 2005-12-06 | 2h | 2.7d | 1.84d | Calendario de trabajo | técnico DPE; ordenador | 2h |
| 31 | 5.7 | manual del S.A.T. |  | 2h | 2005-12-06 | 2005-12-07 | 26, 27 | 2005-12-07 | 2005-12-07 | 2h | 2.11d | 1.36d | Calendario de trabajo | técnico DPE; ordenador | 2h |
| 32 | 5.8 | fin del proyecto | milestone | 0d | 2005-12-10 | 2005-12-10 | 25, 28, 26, 27, 30, 31 | 2005-12-10 | 2005-12-10 | 0d | 0d |  |  |  |  |
